# QH SLM Design v0.1

Schedule from MS Project, 2008-01-28 to 2008-03-18, 7.5 hours a day.
ITSM Partnership

## Calendars

- Standard: Mon-Fri 08:00-12:00, 13:00-17:00; Sat-Sun off.

## Resources

| Resource | Group |
| --- | --- |
| Customer Process Owner 1 | Customer |
| Customer Project Manager | Customer |
| Customer Technical Consultant 1 | Customer |
| Proj/Prog Manager | IP |
| Solution Architect | IP |
| Technical Consultant 1 | IP |
| Training Consultant | IP |

## Schedule

| ID | WBS | Task | Type | Duration | Start | Finish | Predecessors | Total slack | Free slack | Resources | Work | Text1 | Text2 | Text30 |
| --- | --- | --- | --- | --- | --- | --- | --- | --- | --- | --- | --- | --- | --- | --- |
| 1 | 1 | **[Customer] Service Desk Design Phase (Phase 1)** |  | 38.8d | 2008-01-28 | 2008-03-18 |  | 0d |  |  | 740.45h | MS3 |  |  |
| 2 | 1 | **Design Project Mobilisation & Management** |  | 0.8d | 2008-01-28 | 2008-01-28 |  | 0d |  |  | 11.5h | MS3 | 01 |  |
| 3 | 1.1.1 | [PSD] Contract Signed | milestone | 0d | 2008-01-28 | 2008-01-28 |  | 0d |  |  |  | MS3 | 01 |  |
| 4 | 1.1.2 | **ITSM Toolset Design Project Startup Phase** |  | 0.3d | 2008-01-28 | 2008-01-28 |  | 0d |  |  | 11.25h | MS3 | 01 |  |
| 5 | 1.2 | **Design Project Kick-Off** |  | 0.3d | 2008-01-28 | 2008-01-28 |  | 0d |  |  | 11.25h | MS3 | 01 | 1.1 |
| 6 | 1.1.2.1.1 | Start Design Project | milestone | 0d | 2008-01-28 | 2008-01-28 | 3 | 0d |  |  |  | MS3 | 01 |  |
| 7 | 1.1.2.1.2 | Design Project kick-off meeting |  | 0.3d | 2008-01-28 | 2008-01-28 | 6 | 0d |  | Customer Process Owner 1; Customer Project Manager; Customer Technical Consultant 1; Proj/Prog Manager; Solution Architect | 11.25h | MS3 | 01 |  |
| 8 | 1.1.3 | **Design Project Establishment** |  | 0d | 2008-01-28 | 2008-01-28 |  | 35d |  |  |  | MS3 | 01 | 1.3 |
| 9 | 1.1.3.1 | Design Project Establishment Start | milestone | 0d | 2008-01-28 | 2008-01-28 | 7 | 35d | 0d |  |  | MS3 | 01 |  |
| 10 | 1.1.4 | **Design Project Management** |  | 0.5d | 2008-01-28 | 2008-01-28 |  | 35d |  |  | 0.25h | MS3 |  |  |
| 11 | 1.1.4.1 | Design Project Manager Governance Activities |  | 0.5d | 2008-01-28 | 2008-01-28 | 9 | 35d | 2.75d | Proj/Prog Manager [6.7%] | 0.25h | MS3 |  |  |
| 12 | 1.2 | **Design Planning** |  | 6.25d | 2008-01-28 | 2008-02-05 |  | 32.25d |  |  | 54.45h | MS3 |  |  |
| 13 | 1.2.1 | **Design updates to the Project Management Plan** |  | 3.25d | 2008-01-28 | 2008-01-31 |  | 32.25d |  |  | 31.95h | MS3 | 01 |  |
| 14 | 1.2.1.1 | Design Project Approach |  | 0.25d | 2008-01-28 | 2008-01-28 | 7 | 32.25d | 0d | Proj/Prog Manager | 1.88h | MS3 | 01 |  |
| 15 | 1.2.1.2 | Quality Requirements (Quality Plan) |  | 0.25d | 2008-01-28 | 2008-01-28 | 14 | 32.25d | 0d | Solution Architect | 1.88h | MS3 | 01 |  |
| 16 | 1.2.1.3 | Implementation Strategy - Walkthrough |  | 0.25d | 2008-01-28 | 2008-01-28 | 15 | 32.25d | 0d | Proj/Prog Manager; Customer Project Manager | 3.77h | MS3 | 01 |  |
| 17 | 1.2.1.4 | Test Strategy - Walkthrough |  | 0.25d | 2008-01-28 | 2008-01-29 | 16 | 32.25d | 0d | Solution Architect | 1.88h | MS3 | 01 |  |
| 18 | 1.2.1.5 | Design Project Support Requirements |  | 0.25d | 2008-01-29 | 2008-01-29 | 17 | 32.25d | 0d | Solution Architect | 1.88h | MS3 | 01 |  |
| 19 | 1.2.1.6 | Design Project completion criteria |  | 0.25d | 2008-01-28 | 2008-01-29 | 16 | 37.25d | 0d | Proj/Prog Manager | 1.88h | MS3 | 01 |  |
| 20 | 1.2.1.7 | [DEP.01] Client - Establish [Customer] training strategy |  | 0.25d | 2008-01-29 | 2008-01-29 | 19 | 37.25d |  | Customer Process Owner 1; Customer Project Manager | 3.77h | MS3 | 01 |  |
| 21 | 1.2.1.8 | Update the PMP (for the Design and Implementation) |  | 2d | 2008-01-29 | 2008-01-31 | 18 | 32.25d | 0d | Proj/Prog Manager | 15h | MS3 |  |  |
| 22 | 1.2.1.9 | [MIL.01] PMP Updated | milestone | 0d | 2008-01-31 | 2008-01-31 | 21 | 32.25d | 0d |  |  | MS3 |  |  |
| 23 | 1.2.2 | **Design Project Management** |  | 3d | 2008-01-31 | 2008-02-05 |  | 32.25d |  |  | 22.5h | MS3 |  |  |
| 24 | 1.2.2.1 | Design Project Manager Governance Activities |  | 3d | 2008-01-31 | 2008-02-05 | 11, 22 | 32.25d |  | Proj/Prog Manager | 22.5h | MS3 |  |  |

| ID | WBS | Task | Type | Duration | Start | Finish | Predecessors | Total slack | Resources | Work | Text1 |
| --- | --- | --- | --- | --- | --- | --- | --- | --- | --- | --- | --- |
| 25 | 1.3 | **INC, CHG, SLM, CFG Mgt Analysis & Design** |  | 38.8d | 2008-01-28 | 2008-03-18 |  | 0d |  | 674.5h | MS3 |
| 26 | 1.3.1 | **DEL-01 Requirements Confirmation and Approval** |  | 5d | 2008-01-28 | 2008-02-01 |  | 0d |  | 87.2h | MS3 |
| 27 | 1.3.1.1 | [DEP.02] Client - Detailed Requirements Workshops |  | 1.5d | 2008-01-28 | 2008-01-29 | 7 | 0d | Solution Architect; Technical Consultant 1; Customer Process Owner 1; Customer Project Manager; Customer Technical Consultant 1; Proj/Prog Manager [25%] | 59.06h | MS3 |
| 28 | 1.3.1.2 | Develop Training Requirements (ITIL & Tool) |  | 2d | 2008-01-29 | 2008-01-31 | 27 | 0d | Training Consultant | 15h | MS3 |
| 29 | 1.3.1.3 | Develop Requirements traceability matrix |  | 1d | 2008-01-31 | 2008-02-01 | 28 | 0d | Technical Consultant 1; Solution Architect [50%] | 11.25h | MS3 |
| 30 | 1.3.1.4 | Update schedule for Design Phase |  | 0.5d | 2008-02-01 | 2008-02-01 | 29 | 0d | Solution Architect [50%] | 1.88h | MS3 |
| 31 | 1.3.1.5 | [DEL.01] Requirements Traceability Matrix Approved | milestone | 0d | 2008-02-01 | 2008-02-01 | 30 | 0d |  |  | MS3 |
| 32 | 1.3.2 | **DEL-02 Process Design** |  | 29.8d | 2008-01-28 | 2008-03-05 |  | 5.3d |  | 442.87h | MS3 |
| 33 | 1.3.2.1 | **Process Design - INC Management** |  | 3d | 2008-02-01 | 2008-02-06 |  | 0d |  | 33.75h | MS3 |
| 34 | 1.3.2.1.1 | Workshop the INC Mgmt Processes with [Customer] |  | 3d | 2008-02-01 | 2008-02-06 | 31 | 0d | Technical Consultant 1; Solution Architect [50%] | 33.75h | MS3 |
| 35 | 1.3.2.2 | **Process Design - CHG Management** |  | 3d | 2008-02-06 | 2008-02-11 | 34 | 0d |  | 33.75h | MS3 |
| 36 | 1.3.2.2.1 | Workshop the CHG Mgmt Processes with [Customer] |  | 3d | 2008-02-06 | 2008-02-11 |  | 0d | Technical Consultant 1; Solution Architect [50%] | 33.75h | MS3 |
| 37 | 1.3.2.3 | **Process Design - SLM Management** |  | 3d | 2008-01-28 | 2008-01-30 |  | 35.8d |  | 33.75h | MS3 |
| 38 | 1.3.2.3.1 | Workshop the SLM Mgmt Processes with [Customer] |  | 3d | 2008-01-28 | 2008-01-30 |  | 35.8d | Technical Consultant 1; Solution Architect [50%] | 33.75h | MS3 |
| 39 | 1.3.2.4 | **Process Design - CFG Management** |  | 3d | 2008-01-28 | 2008-01-30 |  | 35.8d |  | 33.75h | MS3 |
| 40 | 1.3.2.4.1 | Workshop the CFG Mgmt Processes with [Customer] |  | 3d | 2008-01-28 | 2008-01-30 |  | 35.8d | Technical Consultant 1; Solution Architect [50%] | 33.75h | MS3 |
| 41 | 1.3.2.5 | **Tool Design Workshop** |  | 7.5d | 2008-02-11 | 2008-02-20 |  | 0d |  | 132.55h | MS3 |
| 42 | 1.3.2.5.1 | Workshop Preparation |  | 3d | 2008-02-11 | 2008-02-14 | 35 | 0d | Technical Consultant 1 [50%]; Solution Architect [50%] | 22.5h | MS3 |
| 43 | 1.3.2.5.2 | [DEP.04] Client - Conduct Tool Design Workshop |  | 2d | 2008-02-14 | 2008-02-18 | 42 | 0d | Proj/Prog Manager [50%]; Solution Architect [50%]; Customer Process Owner 1; Customer Project Manager; Customer Technical Consultant 1; Technical Consultant 1 | 75h | MS3 |
| 44 | 1.3.2.5.3 | [DEP.05] Client - Update Data Gathering Document |  | 1.5d | 2008-02-18 | 2008-02-19 | 43 | 0d | Proj/Prog Manager [20%]; Solution Architect [25%]; Customer Process Owner 1 [50%]; Customer Project Manager [50%]; Customer Technical Consultant 1 [50%]; Technical Consultant 1 [50%] | 27.6h | MS3 |
| 45 | 1.3.2.5.4 | [DEP.06] Client - [Customer] review of updated Data Gathering Document |  | 1d | 2008-02-19 | 2008-02-20 | 44 | 0d | Customer Technical Consultant 1 [33%]; Customer Project Manager [33%]; Customer Process Owner 1 [33%] | 7.45h | MS3 |
| 46 | 1.3.2.6 | **Technical Design** |  | 11d | 2008-02-20 | 2008-03-05 |  | 0d |  | 175.32h | MS3 |
| 47 | 1.3.2.6.1 | Document Detailed Design |  | 5d | 2008-02-20 | 2008-02-27 | 45 | 0d | Technical Consultant 1; Solution Architect [50%] | 56.25h | MS3 |
| 48 | 1.3.2.6.2 | [DEP.07] Client - Forward Design to [Customer] for review and feedback |  | 5d | 2008-02-27 | 2008-03-04 | 47 | 0d | Customer Technical Consultant 1; Customer Project Manager; Customer Process Owner 1 | 112.5h | MS3 |
| 49 | 1.3.2.6.3 | Update the Design document |  | 0.5d | 2008-03-05 | 2008-03-05 | 48 | 0d | Solution Architect [50%]; Technical Consultant 1 [50%] | 3.77h | MS3 |
| 50 | 1.3.2.6.4 | [DEL-02] Detailed Design Approved | milestone | 0d | 2008-03-05 | 2008-03-05 | 49 | 0d |  |  | MS3 |
| 51 | 1.3.2.6.5 | Approval of the Detailed Design document |  | 0.5d | 2008-03-05 | 2008-03-05 | 50 | 0d | Technical Consultant 1 [25%]; Solution Architect [25%]; Proj/Prog Manager [25%] | 2.8h | MS3 |
| 52 | 1.3.2.6.6 | [MIL.02] Analysis & Design complete | milestone | 0d | 2008-03-05 | 2008-03-05 | 51 | 0d |  |  | MS3 |

| ID | WBS | Task | Type | Duration | Start | Finish | Predecessors | Total slack | Free slack | Resources | Work | Text1 | Text2 |
| --- | --- | --- | --- | --- | --- | --- | --- | --- | --- | --- | --- | --- | --- |
| 53 | 1.3.3 | **DEL-03 Project Implementation Schedule** |  | 9d | 2008-03-05 | 2008-03-18 |  | 0d |  |  | 69.38h | MS3 |  |
| 54 | 1.3.3.1 | Update the schedule for implementation |  | 1d | 2008-03-05 | 2008-03-06 | 52 | 0d |  | Solution Architect [50%] | 3.75h | MS3 |  |
| 55 | 1.3.3.2 | Update the training schedule for implementation |  | 2d | 2008-03-06 | 2008-03-10 | 54 | 0d |  | Training Consultant | 15h | MS3 |  |
| 56 | 1.3.3.3 | [DEP.08] Client - Review the updated schedule for implementation with [Customer] |  | 5d | 2008-03-10 | 2008-03-17 | 55 | 0d |  | Customer Project Manager [50%]; Customer Technical Consultant 1 [50%] | 37.5h | MS3 |  |
| 57 | 1.3.3.4 | Update the schedule for implementation |  | 1d | 2008-03-17 | 2008-03-18 | 56 | 0d |  | Proj/Prog Manager [50%]; Customer Project Manager; Solution Architect [25%] | 13.13h | MS3 |  |
| 58 | 1.3.3.5 | [DEL-03] Implementation Schedule Approved | milestone | 0d | 2008-03-18 | 2008-03-18 | 51, 57 | 0d |  |  |  | MS3 |  |
| 59 | 1.3.3.6 | [MIL.03] Implementation Schedule Approved | milestone | 0d | 2008-03-18 | 2008-03-18 | 58 | 0d |  |  |  | MS3 |  |
| 60 | 1.3.4 | **DEL-04 Development of Statement of Work for Implementation** |  | 33.5d | 2008-02-01 | 2008-03-18 |  | 0d |  |  | 75.05h | MS3 |  |
| 61 | 1.3.4.1 | Create Statement of work document and pricing |  | 1d | 2008-02-01 | 2008-02-04 | 30 | 28.25d | 0d | Proj/Prog Manager [50%]; Technical Consultant 1 [25%]; Solution Architect [25%] | 7.5h | MS3 | 01 |
| 62 | 1.3.4.2 | Walkthrough PMP, Implementation SOW & schedule |  | 0.25d | 2008-02-04 | 2008-02-05 | 61 | 28.25d | 0d | Proj/Prog Manager; Customer Process Owner 1; Customer Project Manager; Customer Technical Consultant 1; Solution Architect; Technical Consultant 1 | 11.3h | MS3 | 01 |
| 63 | 1.3.4.3 | Finalise the Design Project scope |  | 0.5d | 2008-02-05 | 2008-02-05 | 62 | 28.25d | 0d | Solution Architect | 3.75h | MS3 | 01 |
| 64 | 1.3.4.4 | Update Implementation SOW with feedback |  | 0.5d | 2008-02-05 | 2008-02-06 | 63 | 28.25d | 0d | Solution Architect | 3.75h | MS3 | 01 |
| 65 | 1.3.4.5 | [DEP.03] Client - [Customer] review of Implementation SOW |  | 2d | 2008-02-06 | 2008-02-07 | 64 | 28.25d | 0d | Customer Process Owner 1; Customer Project Manager; Customer Technical Consultant 1 | 45h | MS3 | 01 |
| 66 | 1.3.4.6 | Update with [Customer] feedback |  | 1d | 2008-02-07 | 2008-02-08 | 65 | 28.25d |  | Proj/Prog Manager [50%] | 3.75h | MS3 | 01 |
| 67 | 1.3.4.7 | [DEL.04] Statement of Work for Implementation Approved | milestone | 0d | 2008-03-18 | 2008-03-18 | 66, 58 | 0d |  |  |  | MS3 | 01 |
