# [Customer] ITSM Implementation Phase (Phase 2)

Schedule from MS Project, 2008-06-16 to 2008-10-22, status date 2008-01-16, 7.5 hours a day, A marks actual dates.
Project Schedule
itsm Partnership Pty Ltd
tbr gm

## Calendars

- Standard 37.5 hr week: Mon-Fri 08:30-12:00, 13:00-17:00; Sat-Sun off.

## Resources

| Resource | Group |
| --- | --- |
| Proj/Prog Manager 2 | Project Manager |
| Solution Architect 1 | Solution Architect 1 |
| Technical Consultant 1 | Technical Consultant 1 |
| Customer Process Owner | Customer |
| Customer Technical Consultant | Customer |
| Customer Project Manager | Customer |
| Production TC | Technical Consultant P |

## Schedule

| ID | WBS | Task | Duration | Start | Finish | Predecessors | Complete | Remaining | Baseline start | Baseline finish | Baseline duration | Total slack | Free slack | Constraint | Resources | Work | Actual work | Text1 | Text30 |
| --- | --- | --- | --- | --- | --- | --- | --- | --- | --- | --- | --- | --- | --- | --- | --- | --- | --- | --- | --- |
| 1 | 1 | **Phase 0: Project Mobilisation & Management** | 39.65d | 2008-06-16 A | 2008-08-08 |  | 10% | 35.52d | 2006-03-06 | 2006-08-07 | 110.5d | 53.35d |  |  |  | 273.75h | 28.5h | MS0 |  |
| 2 | 1.2 | **Project Start-up** | 9d | 2008-06-16 A | 2008-06-26 |  | 20% | 7.2d | 2006-03-06 | 2006-08-07 | 110.5d | 84d |  |  |  | 67.5h | 13.5h | MS0 | 0.1 |
| 3 | 1.1.1 | Project kick-off meeting | 0.5d | 2008-06-16 A | 2008-06-16 A |  | 100% |  | 2006-08-07 | 2006-08-07 | 0.5d |  |  |  | Proj/Prog Manager 2; Technical Consultant 1 | 7.5h | 7.5h | MS0 |  |
| 4 | 1.1.2 | Project Management | 8d | 2008-06-16 A | 2008-06-26 | 3 | 10% | 7.2d |  |  |  | 84.5d |  |  | Proj/Prog Manager 2 | 60h | 6h |  |  |
| 5 | 1.1.3 | Requirements Review Workshop | 0.5d | 2008-06-26 A | 2008-06-26 A | 4 | 100% |  | 2006-03-06 | 2006-03-06 | 0.5d |  |  |  |  |  |  | MS0 |  |
| 6 | 1.3 | **Build Dev/Test environment** | 37.65d | 2008-06-18 A | 2008-08-08 |  | 7% | 34.91d | 2006-03-06 | 2006-04-04 | 21.5d | 53.35d |  |  |  | 206.25h | 15h | MS0 |  |
| 7 | 1.3.1 | **Install CA Service Desk** | 3d | 2008-06-18 A | 2008-06-20 |  | 67% | 1d | 2006-04-19 | 2006-05-17 | 21d | 62.47d |  |  |  | 22.5h | 15h | MS0 |  |
| 8 | 1.3.1.1 | Service Desk application basic install in iP Dev Env | 1d | 2008-06-18 A | 2008-06-18 A | 3 | 100% |  | 2006-04-19 | 2006-04-19 | 1d |  |  |  | Technical Consultant 1 | 7.5h | 7.5h | MS0 |  |
| 9 | 1.3.1.2 | Basic Configuration of the Service Desk solution in iP Dev Env | 1d | 2008-06-19 A | 2008-06-19 A | 8 | 100% |  | 2006-05-16 | 2006-05-16 | 1d |  |  |  | Technical Consultant 1 | 7.5h | 7.5h | MS0 |  |
| 10 | 1.3.1.3 | Port Service Desk Configuration from Dev Env to [Customer] Dev Env | 1d | 2008-06-20 | 2008-06-20 | 9 |  |  | 2006-05-17 | 2006-05-17 | 1d | 62.47d | 0d |  | Technical Consultant 1 | 7.5h |  | MS0 |  |
| 11 | 1.3.2 | **Load Reference Data in [Customer] Dev Env** | 23.65d | 2008-07-08 | 2008-08-08 |  |  |  | 2006-04-20 | 2006-08-04 | 76.5d | 42d |  |  |  | 183.75h |  | MS0 |  |
| 12 | 1.3.2.1 | [DEP 0.9] Client - Capture data import detail ready for initial data load | 5d | 2008-07-08 | 2008-07-14 | 3 |  |  | 2006-06-05 | 2006-06-09 | 5d | 42d | 0d |  | Customer Technical Consultant | 37.5h |  | MS0 |  |
| 13 | 1.3.2.2 | Create import templates for Organisation, Support Groups and People | 2d | 2008-07-15 | 2008-07-16 | 12 |  |  | 2006-04-20 | 2006-04-25 | 3d | 56d | 15.65d |  | Solution Architect 1 | 15h |  | MS0 |  |
| 14 | 1.2.2.3 | LDAP Integration | 3.5d | 2008-07-16 | 2008-07-21 | 12 |  |  | 2006-06-12 | 2006-06-13 | 2d | 67.5d |  | start no earlier than 2008-07-16 | Technical Consultant 1 | 26.25h |  | MS0 |  |
| 15 | 1.3.2.3 | [DEP 0.9] Client - Format input/source data for input into Service Desk | 2d | 2008-07-15 | 2008-07-16 | 12 |  |  | 2006-06-12 | 2006-06-13 | 2d | 42d | 0d |  | Customer Technical Consultant | 15h |  | MS0 |  |
| 16 | 1.3.2.4 | [DEP 0.9] Client - Import Organisational Data | 3d | 2008-07-18 | 2008-07-23 | 15 |  |  | 2006-06-14 | 2006-06-16 | 3d | 40.75d | 0d |  | Customer Technical Consultant | 22.5h |  | MS0 |  |
| 17 | 1.3.2.5 | [DEP 0.9] Client - Import People/Support Group Data | 3d | 2008-07-23 | 2008-07-28 | 16 |  |  | 2006-06-19 | 2006-06-21 | 3d | 40.75d | 0d |  | Customer Technical Consultant | 22.5h |  | MS0 |  |
| 18 | 1.3.2.6 | [DEP.10] Client - Capture rules and account details | 5d | 2008-07-31 | 2008-08-07 | 17 |  |  | 2006-06-14 | 2006-06-20 | 5d | 40.35d | 0d |  | Customer Technical Consultant | 37.5h |  | MS0 |  |
| 19 | 1.3.2.7 | Configure Roles as documented in Design Phase | 1d | 2008-08-07 | 2008-08-08 | 13, 18 |  |  | 2006-08-04 | 2006-08-04 | 1d | 40.35d | 5d |  | Solution Architect 1 | 7.5h |  | MS0 |  |
| 20 | 2 | **Phase 1: Configuration Management** | 66.25d | 2008-06-25 | 2008-09-25 |  |  |  | 2006-03-06 | 2006-08-07 | 110.5d | 19.6d |  |  |  | 185.62h |  | MS1 |  |
| 21 | 1.10 | **Configuration Module Build** | 66.25d | 2008-06-25 | 2008-09-25 |  |  |  | 2006-03-06 | 2006-08-04 | 110d | 19.6d |  |  |  | 125.62h |  | MS1 | 1.1 |
| 22 | 2.1.1 | **Service Desk CI Configuration** | 37.5d | 2008-06-25 | 2008-08-15 |  |  |  | 2006-04-20 | 2006-06-09 | 37d | 35.35d |  |  |  | 73.12h |  | MS1 | 1.1.2 |
| 23 | 2.1.1.1 | SD Configuration of custom fields | 1d | 2008-06-25 | 2008-06-26 | 10 |  |  |  |  |  | 62.35d | 0d |  | Technical Consultant 1 | 7.5h |  |  |  |
| 24 | 2.1.1.2 | SD Configuration of Forms | 1d | 2008-06-26 | 2008-06-27 | 23 |  |  |  |  |  | 62.35d | 0d |  | Technical Consultant 1 | 7.5h |  |  |  |
| 25 | 2.1.1.3 | SD Configuration of Business rules | 1d | 2008-06-27 | 2008-06-30 | 24 |  |  |  |  |  | 62.35d | 0d |  | Technical Consultant 1 | 7.5h |  |  |  |
| 26 | 2.1.1.4 | [DEP.11] Client - Development of archiving routines | 2d | 2008-07-01 | 2008-07-02 | 3 |  |  | 2006-05-15 | 2006-05-16 | 2d | 36d | 0d |  | Customer Technical Consultant | 15h |  | MS1 |  |
| 27 | 2.1.1.5 | [DEP 0.9] Client - Capture data import detail ready for initial data load | 5d | 2008-07-17 | 2008-07-23 | 26 |  |  | 2006-05-08 | 2006-05-12 | 5d | 36d | 0d |  | Customer Technical Consultant | 9.38h |  | MS1 |  |
| 28 | 2.1.1.6 | Create import templates for CI's | 3d | 2008-06-30 | 2008-07-03 | 25 |  |  | 2006-04-20 | 2006-04-24 | 3d | 66.85d | 31.5d |  | Technical Consultant 1 [50%] | 11.25h |  | MS1 |  |
| 29 | 2.1.1.7 | [DEP 0.9] Client - Format input/source data for input into Service Desk | 5d | 2008-07-28 | 2008-08-04 | 27, 26 |  |  | 2006-05-17 | 2006-05-18 | 2d | 35.75d | 0d |  | Customer Technical Consultant | 3h |  | MS1 |  |
| 30 | 2.1.1.8 | [DEP 0.9] Client - Import CI Data | 5d | 2008-08-07 | 2008-08-14 | 29 |  |  | 2006-05-19 | 2006-05-23 | 3d | 35.35d | 0d |  | Customer Technical Consultant | 4.5h |  | MS1 |  |
| 31 | 2.1.1.9 | Review and Sign-off the forms, views and templates | 1d | 2008-08-14 | 2008-08-15 | 30 |  |  | 2006-06-09 | 2006-06-09 | 1d | 35.35d | 0d |  | Solution Architect 1; Customer Process Owner | 7.5h |  | MS1 |  |

| ID | WBS | Task | Type | Duration | Start | Finish | Predecessors | Complete | Remaining | Baseline start | Baseline finish | Baseline duration | Total slack | Free slack | Constraint | Resources | Work | Actual work | Text1 | Text30 |
| --- | --- | --- | --- | --- | --- | --- | --- | --- | --- | --- | --- | --- | --- | --- | --- | --- | --- | --- | --- | --- |
| 32 | 2.1.2 | **Service Desk CI Documentation** |  | 28.25d | 2008-08-18 | 2008-09-25 |  |  |  | 2006-06-12 | 2006-07-10 | 21d | 19.6d |  |  |  | 52.5h |  | MS1 | 1.1.3 |
| 33 | 2.1.2.1 | Update Installation & Configuration Guide ([Customer] SIG Format) |  | 2d | 2008-08-18 | 2008-08-20 | 31, 28, 19 |  |  | 2006-06-12 | 2006-06-16 | 5d | 35.45d | 15.85d |  | Technical Consultant 1 | 15h |  | MS1 |  |
| 34 | 2.1.2.2 | Develop Work Instructions - Configuration Management (part of the SMG) |  | 1d | 2008-09-11 | 2008-09-11 | 33 |  |  | 2006-07-03 | 2006-07-04 | 2d | 19.6d | 0d | finish no earlier than 2008-09-11 | Solution Architect 1 | 7.5h |  | MS1 |  |
| 35 | 2.1.2.3 | Configuration Solution Walkthrough (mentoring) |  | 1d | 2008-09-12 | 2008-09-12 | 34, 17 |  |  | 2006-07-05 | 2006-07-05 | 1d | 19.6d | 0d |  | Technical Consultant 1 | 7.5h |  | MS1 |  |
| 36 | 2.1.2.4 | [DEP.01] Client - Customer Review and Approval |  | 8.25d | 2008-09-15 | 2008-09-25 | 33, 35 |  |  | 2006-07-06 | 2006-07-10 | 3d | 19.6d | 0d |  | Customer Process Owner | 22.5h |  | MS1 |  |
| 37 | 2.1.2.5 | [DEL 1.1] Configuration Management Install Guide | milestone | 0d | 2008-09-25 | 2008-09-25 | 36 |  |  | 2006-07-10 | 2006-07-10 | 0d | 19.6d |  |  |  |  |  | MS1 |  |
| 38 | 1.11 | **Configuration Module Unit Testing** |  | 22.35d | 2008-06-30 | 2008-07-30 |  |  |  | 2006-05-18 | 2006-08-07 | 57.5d | 60.5d |  |  |  | 60h |  | MS1 | 1.2 |
| 39 | 2.2.1 | **Configuration Unit Test Planning** |  | 5d | 2008-06-30 | 2008-07-07 |  |  |  | 2006-05-18 | 2006-05-26 | 6.5d | 62.35d |  |  |  | 30h |  | MS1 | 1.2.1 |
| 40 | 1.11.8 | Prepare Unit Test Plan for Configuration Module |  | 2d | 2008-06-30 | 2008-07-02 | 25 |  |  | 2006-05-18 | 2006-05-19 | 2d | 62.35d | 0d |  | Technical Consultant 1 [50%] | 7.5h |  | MS1 |  |
| 41 | 2.2.1.2 | [DEP.01] Client - Customer Review and Approval |  | 3d | 2008-07-02 | 2008-07-07 | 40 |  |  | 2006-05-23 | 2006-05-26 | 3d | 62.35d | 0d |  | Customer Process Owner | 22.5h |  | MS1 |  |
| 42 | 2.2.1.3 | [DEL 1.2] Configuration Management Unit Test Plan | milestone | 0d | 2008-07-07 | 2008-07-07 | 41 |  |  | 2006-05-26 | 2006-05-26 | 0d | 62.35d | 0.35d |  |  |  |  | MS1 |  |
| 43 | 2.2.2 | **Conduct Unit Testing for Configuration** |  | 5.5d | 2008-07-23 | 2008-07-30 |  |  |  | 2006-06-29 | 2006-08-07 | 27.5d | 60.5d |  |  |  | 30h |  | MS1 | 1.2.4 |
| 44 | 2.2.2.1 | Run Unit Test Procedures for Configuration |  | 1d | 2008-07-23 | 2008-07-23 | 42 |  |  | 2006-06-29 | 2006-06-30 | 2d | 62d | 0d |  | Technical Consultant 1 | 7.5h |  | MS1 |  |
| 45 | 2.2.2.2 | Incorporate issues into design/configuration documentation |  | 1d | 2008-07-24 | 2008-07-24 | 44 |  |  | 2006-07-06 | 2006-07-07 | 2d | 64d |  |  | Technical Consultant 1 | 7.5h |  | MS1 |  |
| 46 | 2.2.2.3 | Apply modifications resulting from Unit Testing |  | 1d | 2008-07-25 | 2008-07-25 | 44 |  |  | 2006-07-31 | 2006-08-01 | 1.5d | 61d | 0d |  | Solution Architect 1 | 7.5h |  | MS1 |  |
| 47 | 2.2.2.4 | Rerun req'd tests |  | 1d | 2008-07-29 | 2008-07-30 | 46 |  |  | 2006-08-01 | 2006-08-02 | 1d | 60.5d | 0d |  | Solution Architect 1 | 7.5h |  | MS1 |  |
| 48 | 2.2.3 | [DEL 1.3] Configuration Management Unit Testing Completion | milestone | 0d | 2008-07-30 | 2008-07-30 | 47 |  |  | 2006-08-07 | 2006-08-07 | 0d | 60.5d |  |  |  |  |  | MS1 |  |
| 49 | 2.2.4 | [MIL.01] Phase 1: Configuration Management Complete | milestone | 0d | 2008-07-30 | 2008-07-30 | 47 |  |  | 2006-08-07 | 2006-08-07 | 0d | 60.5d |  |  |  |  |  | MS1 |  |
| 50 | 3 | **Phase 2: Change Management** |  | 41d | 2008-06-16 A | 2008-08-12 |  | 30% | 28.62d | 2006-03-06 | 2006-05-18 | 54d | 51.5d |  |  |  | 195h | 57.75h | MS2 |  |
| 51 | 1.10 | **Change Module Build** |  | 23.5d | 2008-06-16 A | 2008-07-17 |  | 51% | 11.44d | 2006-04-04 | 2006-04-14 | 8.5d | 69d |  |  |  | 116.25h | 57.75h | MS2 | 2.1 |
| 52 | 3.1.1 | **Service Desk Change Configuration** |  | 23.5d | 2008-06-16 A | 2008-07-17 |  | 51% | 11.44d | 2006-04-04 | 2006-04-14 | 8.5d | 69d |  |  |  | 116.25h | 57.75h | MS2 | 2.1.2 |
| 53 | 3.1.1.1 | SD Configuration of custom fields |  | 3d | 2008-06-16 A | 2008-06-19 | 3 | 80% | 0.6d |  |  |  | 13.3d | 0d |  | Technical Consultant 1 | 22.5h | 18h |  |  |
| 54 | 3.1.1.2 | SD Configuration of Forms |  | 1d | 2008-06-19 A | 2008-06-20 | 53 | 80% | 0.2d |  |  |  | 12.5d | 2d |  | Technical Consultant 1 | 7.5h | 6h |  |  |
| 55 | 3.1.1.3 | SD Configuration of Business rules |  | 5d | 2008-06-24 A | 2008-07-01 | 54 | 80% | 1d |  |  |  | 6.5d | 0d |  | Technical Consultant 1 | 37.5h | 30h |  |  |
| 56 | 3.1.1.4 | Update Installation & Configuration Guide (SIG - see above) |  | 1d | 2008-07-01 A | 2008-07-02 | 55 | 50% | 0.5d | 2006-04-04 | 2006-04-05 | 1d | 5.9d | 0.4d |  | Technical Consultant 1 | 7.5h | 3.75h | MS2 |  |
| 57 | 3.1.1.5 | Develop Work Instructions - Change Management (for administrators) |  | 1d | 2008-07-03 | 2008-07-03 | 56 |  |  | 2006-04-04 | 2006-04-10 | 4d | 5.5d | 0d | start no earlier than 2008-07-03 | Customer Technical Consultant; Technical Consultant 1 | 15h |  | MS2 |  |
| 58 | 3.1.1.6 | Change Solution Walkthrough (mentoring) |  | 1d | 2008-07-14 | 2008-07-14 | 57 |  |  | 2006-04-11 | 2006-04-11 | 1d | 69d | 0d |  | Solution Architect 1; Customer Technical Consultant | 15h |  | MS2 |  |
| 59 | 3.1.1.7 | [DEP.01] Client - Customer Review and Approval |  | 3d | 2008-07-15 | 2008-07-17 | 58 |  |  | 2006-04-12 | 2006-04-14 | 3d | 69d | 0d |  | Customer Process Owner | 11.25h |  | MS2 |  |
| 60 | 3.1.1.8 | [DEL 2.1] Change Management Updated Install Guide | milestone | 0d | 2008-07-17 | 2008-07-17 | 59, 56 |  |  | 2006-04-14 | 2006-04-14 | 0d | 69d |  |  |  |  |  | MS2 |  |

Notes:
- 34: Will be high level process based work instructions developed along with Process owner

| ID | WBS | Task | Type | Duration | Start | Finish | Predecessors | Complete | Remaining | Baseline start | Baseline finish | Baseline duration | Total slack | Free slack | Resources | Work | Actual work | Text1 | Text30 |
| --- | --- | --- | --- | --- | --- | --- | --- | --- | --- | --- | --- | --- | --- | --- | --- | --- | --- | --- | --- |
| 61 | 1.11 | **Change Module Unit Testing** |  | 16.5d | 2008-07-21 | 2008-08-12 |  |  |  | 2006-04-10 | 2006-05-18 | 28.5d | 51.5d |  |  | 78.75h |  | MS2 | 2.2 |
| 62 | 3.2.1 | **Change Module Unit Test Planning** |  | 5.5d | 2008-07-21 | 2008-07-28 |  |  |  | 2006-04-10 | 2006-04-17 | 5d | 53d |  |  | 37.5h |  | MS2 | 2.2.1 |
| 63 | 1.11.8 | Prepare Unit Test Plan for change |  | 2d | 2008-07-21 | 2008-07-22 | 57 |  |  | 2006-04-10 | 2006-04-12 | 2d | 53d | 0d | Technical Consultant 1 | 15h |  | MS2 |  |
| 64 | 3.2.1.2 | [DEP.01] Client - Customer Review and Approval |  | 3d | 2008-07-23 | 2008-07-28 | 63 |  |  | 2006-04-12 | 2006-04-17 | 3d | 53d | 0d | Customer Process Owner | 22.5h |  | MS2 |  |
| 65 | 3.2.1.3 | [DEL 2.2] Change Management Unit Testing Plan | milestone | 0d | 2008-07-28 | 2008-07-28 | 64 |  |  | 2006-04-17 | 2006-04-17 | 0d | 53d | 2d |  |  |  | MS2 |  |
| 66 | 3.2.2 | **Conduct Unit Testing for Change** |  | 6.5d | 2008-08-04 | 2008-08-12 |  |  |  | 2006-04-26 | 2006-05-18 | 16.5d | 51d |  |  | 41.25h |  | MS2 | 2.2.4 |
| 67 | 3.2.2.1 | Run Unit Test Procedures for Change |  | 2d | 2008-08-04 | 2008-08-05 | 65 |  |  | 2006-04-26 | 2006-04-28 | 2d | 51d | 0d | Technical Consultant 1 | 15h |  | MS2 |  |
| 68 | 3.2.2.2 | Incorporate issues into design documentation |  | 1d | 2008-08-11 | 2008-08-12 | 67 |  |  | 2006-05-15 | 2006-05-15 | 1d | 51.5d |  | Solution Architect 1 | 7.5h |  | MS2 |  |
| 69 | 3.2.2.3 | Apply modifications resulting from Change Module Unit Testing |  | 2d | 2008-08-06 | 2008-08-07 | 67 |  |  | 2006-05-01 | 2006-05-03 | 2d | 51d | 0d | Solution Architect 1 | 15h |  | MS2 |  |
| 70 | 3.2.2.4 | Rerun req'd tests |  | 0.5d | 2008-08-11 | 2008-08-11 | 69 |  |  | 2006-05-04 | 2006-05-04 | 0.5d | 52.5d | 0d | Solution Architect 1 | 3.75h |  | MS2 |  |
| 71 | 3.2.3 | [DEL 2.3] Change Management Unit Testing Completion | milestone | 0d | 2008-08-11 | 2008-08-11 | 70 |  |  | 2006-05-18 | 2006-05-18 | 0d | 52.5d |  |  |  |  | MS2 |  |
| 72 | 3.2.4 | [MIL.02] Phase 2: Change Management Complete | milestone | 0d | 2008-08-11 | 2008-08-11 | 70 |  |  | 2006-05-18 | 2006-05-18 | 0d | 52.5d |  |  |  |  | MS2 |  |
| 73 | 4 | **Phase 3: Incident/Service Request Management** |  | 36.5d | 2008-06-20 A | 2008-08-11 |  | 18% | 29.82d | 2006-04-05 | 2006-08-07 | 88.5d | 52d |  |  | 176.25h | 32.25h | MS3 |  |
| 74 | 1.10 | **Incident/Service Request Management Build** |  | 19d | 2008-06-20 A | 2008-07-17 |  | 33% | 12.72d | 2006-04-05 | 2006-04-20 | 12d | 69.5d |  |  | 97.5h | 32.25h | MS3 | 3.1 |
| 75 | 4.1.1 | **Service Desk Incident Management Configuration** |  | 19d | 2008-06-20 A | 2008-07-17 |  | 33% | 12.72d | 2006-04-05 | 2006-04-20 | 12d | 69.5d |  |  | 97.5h | 32.25h | MS3 | 3.1.2 |
| 76 | 4.1.1.1 | SD Configuration of custom fields |  | 1d | 2008-06-20 A | 2008-06-23 | 3 | 90% | 0.1d |  |  |  | 9.4d | 0d | Technical Consultant 1 | 7.5h | 6.75h |  |  |
| 77 | 4.1.1.2 | SD Configuration of Forms |  | 1d | 2008-06-23 A | 2008-06-24 | 76 | 90% | 0.1d |  |  |  | 8.5d | 6d | Technical Consultant 1 | 7.5h | 6.75h |  |  |
| 78 | 4.1.1.3 | SD Configuration of Business rules |  | 5d | 2008-07-02 A | 2008-07-09 | 77 | 50% | 2.5d |  |  |  | 0d |  | Technical Consultant 1 | 37.5h | 18.75h |  |  |
| 79 | 4.1.1.4 | Update Installation & Configuration Guide (SIG) |  | 1d | 2008-07-10 | 2008-07-11 | 78 |  |  | 2006-04-05 | 2006-04-06 | 2d | 0d |  | Technical Consultant 1 | 7.5h |  | MS3 |  |
| 80 | 4.1.1.5 | Develop Work Instructions - Incident Management (for administrators) |  | 1d | 2008-07-04 | 2008-07-04 | 57 |  |  | 2006-04-07 | 2006-04-14 | 6d | 5.5d | 4.5d | Customer Technical Consultant [50%]; Technical Consultant 1 | 11.25h |  | MS3 |  |
| 81 | 4.1.1.6 | Incident Management Solution Walkthrough (mentoring) |  | 1d | 2008-07-11 | 2008-07-14 | 80, 79 |  |  | 2006-04-17 | 2006-04-17 | 1d | 1d | 0d | Solution Architect 1; Customer Technical Consultant | 15h |  | MS3 |  |
| 82 | 4.1.1.7 | [DEP.01] Client - Customer Review and Approval |  | 3d | 2008-07-14 | 2008-07-17 | 81 |  |  | 2006-04-18 | 2006-04-20 | 3d | 1d | 0d | Customer Process Owner | 11.25h |  | MS3 |  |
| 83 | 4.1.1.8 | [DEL 3.1] Incident Management Updated Install Guide | milestone | 0d | 2008-07-17 | 2008-07-17 | 82 |  |  | 2006-04-20 | 2006-04-20 | 0d | 69.5d |  |  |  |  | MS3 |  |
| 84 | 1.11 | **Incident Management Unit Testing** |  | 21.5d | 2008-07-11 | 2008-08-11 |  |  |  | 2006-04-07 | 2006-05-05 | 21d | 0d |  |  | 78.75h |  | MS3 | 3.2 |
| 85 | 4.2.1 | **Incident Management Unit Testing Planning** |  | 5d | 2008-07-11 | 2008-07-18 |  |  |  | 2006-04-07 | 2006-04-14 | 6d | 0d |  |  | 37.5h |  | MS3 | 3.2.1 |
| 86 | 1.11.8 | Prepare Unit Testing Plan for Incident Management |  | 2d | 2008-07-11 | 2008-07-15 | 79 |  |  | 2006-04-07 | 2006-04-11 | 3d | 0d |  | Technical Consultant 1 | 15h |  | MS3 |  |
| 87 | 4.2.1.2 | [DEP.01] Client - Customer Review and Approval |  | 3d | 2008-07-15 | 2008-07-18 | 86 |  |  | 2006-04-12 | 2006-04-14 | 3d | 0d |  | Customer Process Owner | 22.5h |  | MS3 |  |
| 88 | 4.2.1.3 | [DEL 3.2] Incident Management Unit Test Plan | milestone | 0d | 2008-07-18 | 2008-07-18 | 87 |  |  | 2006-04-14 | 2006-04-14 | 0d | 0d |  |  |  |  | MS3 |  |

| ID | WBS | Task | Type | Duration | Start | Finish | Predecessors | Baseline start | Baseline finish | Baseline duration | Total slack | Free slack | Constraint | Resources | Work | Text1 | Text30 |
| --- | --- | --- | --- | --- | --- | --- | --- | --- | --- | --- | --- | --- | --- | --- | --- | --- | --- |
| 89 | 4.2.2 | **Conduct Unit Testing for Incident Management** |  | 16d | 2008-07-21 | 2008-08-11 |  | 2006-04-25 | 2006-05-05 | 9d | 0d |  |  |  | 41.25h | MS3 | 3.2.4 |
| 90 | 4.2.2.1 | Run Unit Test Procedures for Incident Management |  | 2d | 2008-07-21 | 2008-07-22 | 88, 82 | 2006-04-25 | 2006-04-26 | 2d | 0d |  |  | Technical Consultant 1 | 15h | MS3 |  |
| 91 | 4.2.2.2 | Incorporate issues into design documentation |  | 1d | 2008-08-11 | 2008-08-11 | 90 | 2006-05-02 | 2006-05-02 | 1d | 52d |  |  | Technical Consultant 1 | 7.5h | MS3 |  |
| 92 | 4.2.2.3 | Apply modifications resulting from Incident Management Unit Testing |  | 1.5d | 2008-07-23 | 2008-07-24 | 90 | 2006-04-27 | 2006-04-28 | 1.5d | 0d |  |  | Technical Consultant 1 | 11.25h | MS3 |  |
| 93 | 4.2.2.4 | Rerun req'd tests |  | 1d | 2008-07-24 | 2008-07-25 | 92 | 2006-05-01 | 2006-05-01 | 0.5d | 0d |  |  | Solution Architect 1 | 7.5h | MS3 |  |
| 94 | 4.2.3 | [DEL 3.3] Incident Management Unit Testing Completion | milestone | 0d | 2008-07-25 | 2008-07-25 | 93 | 2006-05-05 | 2006-05-05 | 0d | 63.5d |  |  |  |  | MS3 |  |
| 95 | 4.2.4 | [MIL.03] Phase 3: Incident Management Complete | milestone | 0d | 2008-07-25 | 2008-07-25 | 93 | 2006-05-05 | 2006-05-05 | 0d | 0d |  |  |  |  | MS3 |  |
| 96 | 1.11 | **Phase 4: System, System Integration & UAT Testing** |  | 38.5d | 2008-07-25 | 2008-09-17 |  | 2006-05-05 | 2006-08-21 | 76d | 0d |  |  |  | 161.25h | MS4 | 3.2 |
| 97 | 5.1 | **System, System Integration & UAT Planning** |  | 6.5d | 2008-07-25 | 2008-08-04 |  | 2006-05-19 | 2006-05-31 | 9d | 0d |  |  |  | 37.5h | MS4 | 3.2.1 |
| 98 | 1.11.8 | Prepare System, System Integration & UAT Test Plan |  | 3d | 2008-07-25 | 2008-07-30 | 95 | 2006-05-19 | 2006-05-25 | 5d | 0d |  |  | Technical Consultant 1 [66.7%] | 15h | MS4 |  |
| 99 | 5.1.3 | [DEP.01] Client - Customer Review and Approval |  | 3d | 2008-07-31 | 2008-08-04 | 98 | 2006-05-29 | 2006-05-31 | 3d | 57d | 0d | finish no earlier than 2008-08-04 | Customer Process Owner | 22.5h | MS4 |  |
| 100 | 5.1.4 | [DEL 4.1] Service Desk System, SI & UAT Plan | milestone | 0d | 2008-08-04 | 2008-08-04 | 99 | 2006-05-31 | 2006-05-31 | 0d | 57d |  |  |  |  | MS4 |  |
| 101 | 5.2 | **Prepare UAT environment** |  | 9.5d | 2008-07-30 | 2008-08-12 |  | 2006-05-26 | 2006-06-01 | 5d | 0d |  |  |  | 22.5h | MS4 | 3.2.2 |
| 102 | 5.2.1 | [DEP 0.3] Client - Arrange UAT Facilities |  | 1d | 2008-07-30 | 2008-07-31 | 98 | 2006-05-26 | 2006-05-26 | 1d | 0d |  |  | Customer Project Manager | 7.5h | MS4 |  |
| 103 | 5.2.2 | [DEP 0.3] Client - Create UAT environment |  | 2d | 2008-08-11 | 2008-08-12 | 102 | 2006-05-31 | 2006-06-01 | 2d | 0d |  |  | Customer Technical Consultant | 15h | MS4 |  |
| 104 | 5.3 | **Handover to UAT Users** |  | 1.5d | 2008-08-13 | 2008-08-14 |  | 2006-06-02 | 2006-06-05 | 1.5d | 0d |  |  |  | 11.25h | MS4 | 3.2.3 |
| 105 | 5.3.1 | Run User Handover session for UAT team (Single Session) |  | 1d | 2008-08-13 | 2008-08-13 | 103 | 2006-06-02 | 2006-06-02 | 1d | 0d |  |  | Technical Consultant 1 | 7.5h | MS4 |  |
| 106 | 5.3.2 | Incorporate feedback into handover material |  | 0.5d | 2008-08-14 | 2008-08-14 | 105 | 2006-06-05 | 2006-06-05 | 0.5d | 0d |  |  | Technical Consultant 1 | 3.75h | MS4 |  |
| 107 | 5.4 | **Conduct System, System Integration & UAT Testing** |  | 24.5d | 2008-08-14 | 2008-09-17 |  | 2006-06-05 | 2006-08-15 | 51.5d | 0d |  |  |  | 90h | MS4 | 3.2.4 |
| 108 | 5.4.3 | [DEP 0.3] Client - Run UAT Test Cases |  | 2d | 2008-08-14 | 2008-08-18 | 106 | 2006-07-04 | 2006-08-07 | 25d | 0d |  |  | Customer Technical Consultant | 15h | MS4 |  |
| 109 | 5.4.4 | [DEP 0.3] Client - Run Operational Test Cases |  | 1d | 2008-08-18 | 2008-08-19 | 108 | 2006-07-04 | 2006-08-07 | 25d | 0d |  |  | Customer Technical Consultant | 7.5h | MS4 |  |
| 110 | 5.4.6 | Incorporate issues found in UAT testing into design documentation |  | 2d | 2008-08-20 | 2008-08-22 | 109 | 2006-08-08 | 2006-08-10 | 3d | 2d | 0.5d |  | Production TC [50%] | 7.5h | MS4 |  |
| 111 | 5.4.7 | Update Work Instructions (for administrators) |  | 1d | 2008-09-17 | 2008-09-17 | 110 | 2006-08-14 | 2006-08-15 | 2d | 25d | 0d |  | Customer Technical Consultant [33.3%]; Production TC [66.7%] | 7.5h | MS4 |  |
| 112 | 5.4.8 | Apply modifications resulting from System, SI & UAT |  | 1d | 2008-08-19 | 2008-08-20 | 109 | 2006-07-03 | 2006-07-04 | 2d | 0d |  |  | Production TC | 7.5h | MS4 |  |
| 113 | 5.4.9 | [Customer] CAB Stage 1 approval |  | 1d | 2008-08-21 | 2008-08-22 | 112 | 2006-07-05 | 2006-07-05 | 1d | 0d |  |  | Customer Technical Consultant | 7.5h | MS4 |  |
| 114 | 5.4.10 | Rerun req'd tests |  | 2d | 2008-08-22 | 2008-08-26 | 113 | 2006-07-06 | 2006-07-12 | 5d | 0d |  |  | Customer Technical Consultant | 15h | MS4 |  |
| 115 | 5.4.11 | [DEP.01] Client - Customer Review and Approval |  | 3d | 2008-08-26 | 2008-08-29 | 110, 114 | 2006-08-11 | 2006-08-15 | 3d | 0d |  |  | Customer Process Owner | 22.5h | MS4 |  |
| 116 | 5.5 | [DEL 4.2] Service Desk System, SI & UAT Completion | milestone | 0d | 2008-08-29 | 2008-08-29 | 115 | 2006-08-15 | 2006-08-15 | 0d | 38.5d |  |  |  |  | MS4 |  |
| 117 | 5.6 | [MIL.04] Phase 4: System, System Integration & UAT Testing Complete | milestone | 0d | 2008-09-17 | 2008-09-17 | 115, 111 | 2006-08-15 | 2006-08-15 | 0d | 25d |  |  |  |  | MS4 |  |

| ID | WBS | Task | Type | Duration | Start | Finish | Predecessors | Baseline start | Baseline finish | Baseline duration | Total slack | Free slack | Resources | Work | Text1 | Text30 |
| --- | --- | --- | --- | --- | --- | --- | --- | --- | --- | --- | --- | --- | --- | --- | --- | --- |
| 118 | 6 | **Phase 5: Production Build and Configuration** |  | 22d | 2008-09-01 | 2008-09-30 |  | 2006-06-19 | 2006-09-04 | 56d | 0d |  |  | 154.5h | MS5 |  |
| 119 | 6.1 | **Deploy to Production** |  | 21d | 2008-09-01 | 2008-09-29 |  | 2006-06-19 | 2006-09-04 | 56d | 0d |  |  | 153.75h | MS5 | 4.1 |
| 120 | 6.1.1 | **Handover** |  | 1d | 2008-09-01 | 2008-09-01 |  | 2006-08-16 | 2006-08-16 | 1d | 0d |  |  | 3.75h | MS5 | 4.1.1 |
| 121 | 6.1.1.1 | Conduct Handover session (not training) |  | 1d | 2008-09-01 | 2008-09-01 | 93, 115 | 2006-08-16 | 2006-08-16 | 1d | 0d |  | Technical Consultant 1 [50%] | 3.75h | MS5 |  |
| 122 | 6.1.2 | **Production Environment Build** |  | 13d | 2008-09-02 | 2008-09-18 |  | 2006-06-19 | 2006-08-16 | 43d | 0d |  |  | 97.5h | MS5 | 4.1.2 |
| 123 | 6.1.2.1 | [DEP 0.3] Client - Production environment build activities |  | 5d | 2008-09-02 | 2008-09-08 | 121 | 2006-06-19 | 2006-06-23 | 5d | 0d |  | Customer Technical Consultant | 37.5h | MS5 |  |
| 124 | 6.1.2.2 | [DEP 0.4] Client - Install Service Desk Client software (Web Configuration) |  | 3d | 2008-09-09 | 2008-09-11 | 123 | 2006-07-31 | 2006-08-02 | 3d | 0d |  | Customer Technical Consultant | 22.5h | MS5 |  |
| 125 | 6.1.2.3 | [DEP 0.5] Client - Creation of the backup strategy documentation for Operations |  | 5d | 2008-09-12 | 2008-09-18 | 124 | 2006-08-03 | 2006-08-09 | 5d | 0d |  | Customer Technical Consultant | 37.5h | MS5 |  |
| 126 | 6.1.3 | **Production Migration** |  | 4d | 2008-09-19 | 2008-09-24 |  | 2006-08-16 | 2006-08-25 | 8d | 0d |  |  | 30h | MS5 |  |
| 127 | 6.1.3.1 | [Customer] Production CAB |  | 1d | 2008-09-19 | 2008-09-19 | 125, 110 | 2006-08-16 | 2006-08-17 | 2d | 0d |  | Customer Technical Consultant | 7.5h | MS5 |  |
| 128 | 6.1.3.2 | Review the customer's requirements (Tracability matrix) |  | 1d | 2008-09-22 | 2008-09-22 | 127 | 2006-08-18 | 2006-08-18 | 1d | 0d |  | Production TC | 7.5h | MS5 |  |
| 129 | 6.1.3.3 | Apply minor changes from the review process |  | 1d | 2008-09-23 | 2008-09-23 | 128 | 2006-08-21 | 2006-08-23 | 3d | 0d |  | Production TC | 7.5h | MS5 |  |
| 130 | 6.1.3.4 | Migration & Pre Go Live checks |  | 1d | 2008-09-24 | 2008-09-24 | 129 | 2006-08-24 | 2006-08-25 | 2d | 0d |  | Production TC | 7.5h | MS5 |  |
| 131 | 6.1.4 | Go Live | milestone | 0d | 2008-09-24 | 2008-09-24 | 130 | 2006-08-25 | 2006-08-25 | 0d | 0d |  |  |  | MS5 |  |
| 132 | 6.1.5 | [DEP 0.1] Client - Customer Review and Approval |  | 3d | 2008-09-25 | 2008-09-29 | 131 | 2006-08-30 | 2006-09-01 | 3d | 16d | 0d | Customer Process Owner | 22.5h | MS5 |  |
| 133 | 6.1.6 | [DEL 5] Phase 5 Production Release | milestone | 0d | 2008-09-29 | 2008-09-29 | 132 | 2006-09-01 | 2006-09-01 | 0d | 16d | 0d |  |  | MS5 |  |
| 134 | 6.1.7.2 | [MIL.05] Phase 5: Migrate SD to Production Environment Complete | milestone | 0d | 2008-09-29 | 2008-09-29 | 133 | 2006-09-01 | 2006-09-01 | 0d | 16d | 0d |  |  | MS5 |  |
| 135 | 1.14 | **Phase 6: Project Closure** |  | 1d | 2008-09-30 | 2008-09-30 |  | 2006-08-28 | 2006-09-05 | 7d | 16d |  |  | 0.75h | MS6 |  |
| 136 | 7.2 | Closeout Review |  | 1d | 2008-09-30 | 2008-09-30 | 134 | 2006-09-05 | 2006-09-05 | 1d | 16d | 0d | Proj/Prog Manager 2 [10%] | 0.75h | MS6 |  |
| 137 | 7.3 | [DEL 6] Project Completion | milestone | 0d | 2008-09-30 | 2008-09-30 | 136 | 2006-09-05 | 2006-09-05 | 0d | 16d | 0d |  |  | MS6 |  |
| 138 | 1.14.9 | [MIL.06] Project Closure | milestone | 0d | 2008-09-30 | 2008-09-30 | 137 | 2006-09-05 | 2006-09-05 | 0d | 16d |  |  |  | MS6 |  |
| 139 | 1.13 | **Warranty/Support** |  | 20d | 2008-09-25 | 2008-10-22 |  | 2006-09-01 | 2006-09-28 | 20d | 0d |  |  |  | MS7 |  |
| 140 | 8.1 | 30 day post implementation warranty |  | 20d | 2008-09-25 | 2008-10-22 | 131 | 2006-09-01 | 2006-09-28 | 20d | 0d |  |  |  | MS7 |  |

Notes:
- 128: Any pending actions and reviews due to the integration of Incident, Change and Configuration module, while most of these issues are expected to be covered during UAT.
